| id | name | startDate | endDate | priority | barScale | progress | type | parentId | dependencies |
| --- | --- | --- | --- | --- | --- | --- | --- | --- | --- |
| 1 | Custom Home Build | 2026-06-01T00:00:00.000Z | 2027-07-26T00:00:00.000Z | medium | 1 | 0 | group |  |  |
| 2 | Schematic design | 2026-06-01T00:00:00.000Z | 2026-07-01T00:00:00.000Z | medium | 1 | 0 | task | 1 |  |
| 3 | Construction documents | 2026-07-01T00:00:00.000Z | 2026-07-31T00:00:00.000Z | medium | 1 | 0 | task | 1 | 2 FS |
| 4 | Engineering | 2026-07-16T00:00:00.000Z | 2026-08-06T00:00:00.000Z | medium | 1 | 0 | task | 1 |  |
| 5 | Builder contract | 2026-07-31T00:00:00.000Z | 2026-08-14T00:00:00.000Z | medium | 1 | 0 | task | 1 |  |
| 6 | Submit for permit | 2026-08-15T00:00:00.000Z | 2026-08-16T00:00:00.000Z | medium | 1 | 0 | milestone | 1 | 3 FS |
| 7 | Permit review | 2026-08-15T00:00:00.000Z | 2026-09-29T00:00:00.000Z | medium | 1 | 0 | task | 1 |  |
| 8 | Site clearing and grading | 2026-09-29T00:00:00.000Z | 2026-10-13T00:00:00.000Z | medium | 1 | 0 | task | 1 | 7 FS |
| 9 | Foundation | 2026-10-13T00:00:00.000Z | 2026-11-03T00:00:00.000Z | medium | 1 | 0 | task | 1 | 8 FS |
| 10 | Foundation inspection | 2026-11-03T00:00:00.000Z | 2026-11-04T00:00:00.000Z | medium | 1 | 0 | milestone | 1 |  |
| 11 | Framing | 2026-11-04T00:00:00.000Z | 2026-12-09T00:00:00.000Z | medium | 1 | 0 | task | 1 | 10 FS |
| 12 | Roof and windows | 2026-11-28T00:00:00.000Z | 2026-12-19T00:00:00.000Z | medium | 1 | 0 | task | 1 |  |
| 13 | Dry-in milestone | 2026-12-19T00:00:00.000Z | 2026-12-20T00:00:00.000Z | medium | 1 | 0 | milestone | 1 |  |
| 14 | Plumbing rough-in | 2026-12-28T00:00:00.000Z | 2027-01-11T00:00:00.000Z | medium | 1 | 0 | task | 1 |  |
| 15 | Electrical rough-in | 2027-01-02T00:00:00.000Z | 2027-01-16T00:00:00.000Z | medium | 1 | 0 | task | 1 |  |
| 16 | HVAC rough-in | 2027-01-07T00:00:00.000Z | 2027-01-17T00:00:00.000Z | medium | 1 | 0 | task | 1 |  |
| 17 | Insulation | 2027-01-27T00:00:00.000Z | 2027-02-06T00:00:00.000Z | medium | 1 | 0 | task | 1 |  |
| 18 | Drywall | 2027-02-11T00:00:00.000Z | 2027-03-04T00:00:00.000Z | medium | 1 | 0 | task | 1 | 17 FS |
| 19 | Paint | 2027-03-13T00:00:00.000Z | 2027-04-03T00:00:00.000Z | medium | 1 | 0 | task | 1 |  |
| 20 | Cabinets and counters | 2027-04-07T00:00:00.000Z | 2027-04-28T00:00:00.000Z | medium | 1 | 0 | task | 1 |  |
| 21 | Tile and flooring | 2027-04-17T00:00:00.000Z | 2027-05-08T00:00:00.000Z | medium | 1 | 0 | task | 1 |  |
| 22 | Trim and millwork | 2027-05-07T00:00:00.000Z | 2027-05-21T00:00:00.000Z | medium | 1 | 0 | task | 1 |  |
| 23 | Plumbing and electrical trim | 2027-05-22T00:00:00.000Z | 2027-06-05T00:00:00.000Z | medium | 1 | 0 | task | 1 |  |
| 24 | Exterior finishes | 2027-03-28T00:00:00.000Z | 2027-04-27T00:00:00.000Z | medium | 1 | 0 | task | 1 |  |
| 25 | Driveway and landscaping | 2027-06-06T00:00:00.000Z | 2027-06-27T00:00:00.000Z | medium | 1 | 0 | task | 1 |  |
| 26 | Final inspections | 2027-07-01T00:00:00.000Z | 2027-07-08T00:00:00.000Z | medium | 1 | 0 | milestone | 1 |  |
| 27 | Certificate of occupancy | 2027-07-11T00:00:00.000Z | 2027-07-12T00:00:00.000Z | high | 1 | 0 | milestone | 1 |  |
| 28 | Punch list | 2027-07-11T00:00:00.000Z | 2027-07-21T00:00:00.000Z | medium | 1 | 0 | task | 1 |  |
| 29 | Move in | 2027-07-25T00:00:00.000Z | 2027-07-26T00:00:00.000Z | medium | 1 | 0 | milestone | 1 |  |
